# MyGanttPlanV0French

Schedule from MS Project, 2015-06-01 to 2034-12-31, 7 hours a day.
Ganil

## Calendars

- Standard: Mon-Fri 09:00-12:00, 14:00-18:00; Sat-Sun off.

## Resources

| Resource |
| --- |
| IJCLAB |
| IP2I |
| INFN |
| STFC |
| LIverpool University |
| IPHC |
| Salamanca University |
| University of Koeln |
| Irfu |
| University of Jyvaskyla |
| FAIR |
| IFIC |
| University of Valencia |
| GANIL |
| All |
| MIRION |
| CTT |
| IPHC -L. Charles |
| IPHC Ch. Bonnin |

## Schedule

| ID | WBS | Task | Type | Duration | Start | Finish | Predecessors | Total slack | Resources | Work |
| --- | --- | --- | --- | --- | --- | --- | --- | --- | --- | --- |
| 1 | 1 | **Experimental Campaigns** |  | 5110d | 2015-06-01 | 2034-12-31 |  | 0d |  |  |
| 2 | 1.1 | GANIL | manual | 1589d | 2015-06-01 | 2021-07-01 |  |  |  |  |
| 3 | 1.2 | LNL | manual | 1044d | 2022-01-01 | 2025-12-31 |  |  |  |  |
| 4 | 1.3 | FAIR | manual | 783d | 2026-01-01 | 2028-12-31 |  |  |  |  |
| 5 | 1.4 | Other Campaign | manual | 1561d | 2029-01-08 | 2034-12-31 |  |  |  |  |
| 6 | 2 | **AGATA Pi Milestone for 180 crystals** |  | 3000d | 2021-01-01 | 2032-07-02 |  | 0d |  |  |
| 7 | 2.1 | 1Pi | milestone, manual | 0d | 2021-01-01 | 2021-01-01 |  |  |  |  |
| 8 | 2.2 | 2Pi | milestone, manual | 0d | 2025-07-02 | 2025-07-02 | 16, 27, 38, 137 |  |  |  |
| 9 | 2.3 | 3Pi | milestone, manual | 0d | 2029-07-02 | 2029-07-02 | 20, 31, 42, 139, 95 |  |  |  |
| 10 | 2.4 | 4Pi | milestone, manual | 0d | 2032-07-02 | 2032-07-02 | 23, 34, 45, 141, 96 |  |  |  |
| 11 | 3 | **Detectors Modules** |  | 3262d | 2020-01-01 | 2032-07-01 |  | 0d |  | 84063h |
| 12 | 3.1 | **Detectors Procurement** |  | 3262d | 2020-01-01 | 2032-07-01 |  | 0d |  | 84063h |
| 13 | 3.1.1 | **Capsulse Procurement** |  | 3132d | 2020-01-01 | 2032-01-01 |  | 0d |  | 21938h |
| 14 | 3.1.1.1 | Millestone #72 | manual | 784d | 2020-01-01 | 2022-12-31 |  |  | MIRION | 5488h |
| 15 | 3.1.1.2 | M84 | manual | 261d | 2023-01-02 | 2024-01-01 | 14 |  | MIRION | 1827h |
| 16 | 3.1.1.3 | M96 | manual | 262d | 2024-01-02 | 2025-01-01 | 15 |  | MIRION | 1834h |
| 17 | 3.1.1.4 | M108 | manual | 261d | 2025-01-02 | 2026-01-01 | 16 |  | MIRION | 1827h |
| 18 | 3.1.1.5 | M120 | manual | 261d | 2026-01-02 | 2027-01-01 | 17 |  | MIRION | 1827h |
| 19 | 3.1.1.6 | M132 | manual | 261d | 2027-01-04 | 2028-01-01 | 18 |  | MIRION | 1827h |
| 20 | 3.1.1.7 | M144 | manual | 261d | 2028-01-03 | 2029-01-01 | 19 |  | MIRION | 1827h |
| 21 | 3.1.1.8 | M156 | manual | 261d | 2029-01-02 | 2030-01-01 | 20 |  | MIRION | 1827h |
| 22 | 3.1.1.9 | M168 | manual | 261d | 2030-01-02 | 2031-01-01 | 21 |  | MIRION | 1827h |
| 23 | 3.1.1.10 | M180 | manual | 261d | 2031-01-02 | 2032-01-01 | 22 |  | MIRION | 1827h |
| 24 | 3.1.2 | **Cryostat Procurement** |  | 2999d | 2020-01-01 | 2031-06-30 |  | 0d |  | 21014h |
| 25 | 3.1.2.1 | M24 | manual | 652d | 2020-01-01 | 2022-06-30 |  |  | CTT | 4564h |
| 26 | 3.1.2.2 | M28 | manual | 261d | 2022-07-01 | 2023-06-30 | 25 |  | CTT | 1827h |
| 27 | 3.1.2.3 | M32 | manual | 261d | 2023-07-03 | 2024-06-30 | 26 |  | CTT | 1827h |
| 28 | 3.1.2.4 | M36 | manual | 261d | 2024-07-01 | 2025-06-30 | 27 |  | CTT | 1827h |
| 29 | 3.1.2.5 | M40 | manual | 261d | 2025-07-01 | 2026-06-30 | 28 |  | CTT | 1827h |
| 30 | 3.1.2.6 | M44 | manual | 261d | 2026-07-01 | 2027-06-30 | 29 |  | CTT | 1827h |
| 31 | 3.1.2.7 | M48 | manual | 262d | 2027-07-01 | 2028-06-30 | 30 |  | CTT | 1834h |
| 32 | 3.1.2.8 | M52 | manual | 261d | 2028-07-03 | 2029-06-30 | 31 |  | CTT | 1827h |
| 33 | 3.1.2.9 | M56 | manual | 261d | 2029-07-02 | 2030-06-30 | 32 |  | CTT | 1827h |
| 34 | 3.1.2.10 | M60 | manual | 261d | 2030-07-01 | 2031-06-30 | 33 |  | CTT | 1827h |

| ID | WBS | Task | Type | Duration | Start | Finish | Predecessors | Total slack | Resources | Work |
| --- | --- | --- | --- | --- | --- | --- | --- | --- | --- | --- |
| 35 | 3.1.3 | **Delivered Clusters** |  | 3262d | 2020-01-01 | 2032-07-01 |  | 0d |  | 22855h |
| 36 | 3.1.3.1 | M24 | manual | 914d | 2020-01-01 | 2023-07-01 |  |  | University of Koeln | 6398h |
| 37 | 3.1.3.2 | M28 | manual | 261d | 2023-07-03 | 2024-07-01 | 36 |  | University of Koeln | 1827h |
| 38 | 3.1.3.3 | M32 | manual | 261d | 2024-07-02 | 2025-07-01 | 37 |  | University of Koeln | 1827h |
| 39 | 3.1.3.4 | M36 | manual | 261d | 2025-07-02 | 2026-07-01 | 38 |  | University of Koeln | 1827h |
| 40 | 3.1.3.5 | M40 | manual | 261d | 2026-07-02 | 2027-07-01 | 39 |  | University of Koeln | 1827h |
| 41 | 3.1.3.6 | M44 | manual | 262d | 2027-07-02 | 2028-07-01 | 40 |  | University of Koeln | 1834h |
| 42 | 3.1.3.7 | M48 | manual | 261d | 2028-07-03 | 2029-07-01 | 41 |  | University of Koeln | 1827h |
| 43 | 3.1.3.8 | M52 | manual | 261d | 2029-07-02 | 2030-07-01 | 42 |  | University of Koeln | 1827h |
| 44 | 3.1.3.9 | M54 | manual | 261d | 2030-07-02 | 2031-07-01 | 43 |  | University of Koeln | 1827h |
| 45 | 3.1.3.10 | M60 | manual | 262d | 2031-07-02 | 2032-07-01 | 44 |  | University of Koeln | 1834h |
| 46 | 3.1.4 | Preamplis | manual | 2608d | 2021-01-01 | 2030-12-31 |  |  | GANIL | 18256h |
| 47 | 4 | **Front End Electronic** |  | 3652d | 2017-01-01 | 2030-12-31 |  | 0d |  | 205702h |
| 48 | 4.1 | **Digitizers** |  | 261d | 2017-01-02 | 2018-01-01 |  | 0d |  | 1827h |
| 49 | 4.1.1 | DIGOPT12 - Re-Design | manual | 261d | 2017-01-02 | 2018-01-01 |  |  | INFN | 1827h |
| 50 | 4.2 | **Preprocessing** |  | 2349d | 2017-01-01 | 2026-01-02 |  | 0d |  | 123403h |
| 51 | 4.2.1 | **STARE** |  | 1567d | 2017-01-01 | 2022-12-31 |  |  |  | 15512h |
| 52 | 4.2.1.1 | STARE Board design | manual | 655d | 2017-01-02 | 2019-07-05 |  |  | IJCLAB | 4585h |
| 53 | 4.2.1.2 | STARE Prototype | manual | 432d | 2019-07-05 | 2021-03-01 | 52 |  | IJCLAB | 3024h |
| 54 | 4.2.1.3 | STARE Firmware | manual | 392d | 2020-01-01 | 2021-07-01 |  |  | IJCLAB | 2744h |
| 55 | 4.2.1.4 | STARE pré-series production | manual | 83d | 2021-09-01 | 2021-12-24 |  |  | IJCLAB | 581h |
| 56 | 4.2.1.5 | UDP Read-Out and Crystal Producer Dev from STARE 10Gb/sec | manual | 654d | 2019-07-02 | 2021-12-31 |  |  | IJCLAB | 4578h |
| 57 | 4.2.2 | **PACE** |  | 1650d | 2017-01-01 | 2023-04-28 |  | 0d |  | 66353h |
| 58 | 4.2.2.1 | **Hardware** |  | 1300d | 2017-01-01 | 2021-12-24 |  | 0d | IFIC | 28854h |
| 59 | 4.2.2.1.1 | IDM Deserializer Developpment | manual | 110d | 2020-01-01 | 2020-06-02 |  |  | IFIC; University of Valencia | 1540h |
| 60 | 4.2.2.1.2 | IDM+PACE Concentrator Board R&D | manual | 655d? | 2017-01-01 | 2019-07-04 |  |  | IFIC; University of Valencia | 9170h |
| 61 | 4.2.2.1.3 | IDM+PACE Concentrator Board prototype #3 Tests | manual | 646d | 2019-07-05 | 2021-12-24 | 60 |  | IFIC; University of Valencia | 9044h |

| ID | WBS | Task | Type | Duration | Start | Finish | Predecessors | Total slack | Resources | Work |
| --- | --- | --- | --- | --- | --- | --- | --- | --- | --- | --- |
| 62 | 4.2.2.2 | **CAP** |  | 1650d | 2017-01-01 | 2023-04-28 |  | 0d | IPHC -L. Charles | 37499h |
| 63 | 4.2.2.2.1 | Firmware CERDES | manual | 1126d | 2017-01-01 | 2021-04-23 | 49, 60 |  | IFIC; University of Valencia | 15764h |
| 64 | 4.2.2.2.2 | Firmware GTS | manual | 1126d | 2017-01-01 | 2021-04-23 |  |  | GANIL | 7882h |
| 65 | 4.2.2.2.3 | Firmware STELLA | manual | 67d | 2022-09-01 | 2022-12-02 |  |  | IPHC -L. Charles | 469h |
| 66 | 4.2.2.2.4 | Firmware Event Builder | manual | 67d | 2022-09-01 | 2022-12-02 |  |  | IPHC -L. Charles | 469h |
| 67 | 4.2.2.2.5 | Firmware SSC | manual | 67d | 2022-09-01 | 2022-12-02 |  |  | IPHC -L. Charles | 469h |
| 68 | 4.2.2.2.6 | Firmware CAP | manual | 105d | 2022-12-05 | 2023-04-28 | 67, 66, 65, 64, 63 |  | IPHC -L. Charles | 735h |
| 69 | 4.2.2.2.7 | Data Transfer from CAP to STARE Aurora line | manual | 23d | 2021-09-01 | 2021-10-01 |  |  | IFIC | 161h |
| 70 | 4.2.3 | **Slow Control** |  | 631d | 2021-01-01 | 2023-06-02 |  | 0d |  | 1260h |
| 71 | 4.2.3.1 | CAP-PACE-STARE Ipbus interface | manual | 130d | 2021-01-01 | 2021-07-01 |  |  | IJCLAB | 910h |
| 72 | 4.2.3.2 | Python script coordination | manual | 25d | 2023-05-01 | 2023-06-02 |  |  | IPHC Ch. Bonnin | 175h |
| 73 | 4.2.3.3 | General Electronic Control Interface Generator | manual | 25d | 2023-05-01 | 2023-06-02 |  |  | IJCLAB | 175h |
| 74 | 4.2.4 | **Mechanics, Power Supply and Cooling** |  | 392d | 2020-01-01 | 2021-07-01 |  | 0d |  | 5047h |
| 75 | 4.2.4.1 | Power Supply | manual | 197d | 2020-01-01 | 2020-10-01 |  |  | University of Valencia | 1379h |
| 76 | 4.2.4.2 | Cooling | manual | 262d | 2020-07-01 | 2021-07-01 |  |  | IFIC; University of Valencia | 3668h |
| 77 | 4.2.5 | **Clock and Trigger Hardware** |  | 1828d | 2019-01-01 | 2026-01-02 |  | 0d |  | 33369h |
| 78 | 4.2.5.1 | Trigger Processor for GTS | manual | 631d | 2019-01-01 | 2021-06-01 |  |  | GANIL | 4417h |
| 79 | 4.2.5.2 | GTS Migration to phase2 on Kit | manual | 240d | 2020-01-01 | 2020-12-01 |  |  | IPHC; GANIL | 3360h |
| 80 | 4.2.5.3 | SMART Phase 1 with clock distribution design | manual | 784d | 2019-01-01 | 2021-12-31 |  |  | GANIL; IPHC | 10976h |
| 81 | 4.2.5.4 | Clock and trigger less mode validation in an AGATA channel | milestone, manual | 0d | 2022-01-03 | 2022-01-03 | 80 |  |  |  |
| 82 | 4.2.5.5 | SMART Phase 2 including hardware trigger and large scale | manual | 1044d | 2022-01-03 | 2026-01-01 | 81 |  | GANIL; IPHC | 14616h |
| 83 | 4.2.5.6 | SMART Operationnal for AGATA | milestone, manual | 0d | 2026-01-02 | 2026-01-02 | 82 |  | GANIL; IPHC |  |
| 84 | 4.2.6 | **Test and validation** |  | 499d | 2021-06-01 | 2023-05-01 |  | 0d |  | 1862h |
| 85 | 4.2.6.1 | PACE coupled with STARE- Burning Test | manual | 23d | 2021-06-01 | 2021-07-01 |  |  | IJCLAB; IFIC | 322h |
| 86 | 4.2.6.2 | PACE Proto2 - DIGOPT12+ STARE + SOM readout | manual | 65d | 2021-07-02 | 2021-09-30 | 85 |  | IJCLAB; IFIC | 910h |
| 87 | 4.2.6.3 | PACE-STARE-Readout-with-Cheap CAP Firmware-with detectors | manual | 45d | 2021-10-04 | 2021-12-03 | 69, 86, 71 |  | IJCLAB; IFIC | 630h |
| 88 | 4.2.6.4 | PACE-STARE-CAP-Operational firmware | milestone, manual | 0d | 2023-05-01 | 2023-05-01 | 69, 65, 66, 67, 68 |  | IJCLAB; IFIC |  |

| ID | WBS | Task | Type | Duration | Start | Finish | Predecessors | Total slack | Resources | Work |
| --- | --- | --- | --- | --- | --- | --- | --- | --- | --- | --- |
| 89 | 4.3 | **Phase 2 Production** |  | 2002d | 2023-05-01 | 2030-12-31 |  | 0d |  | 69468h |
| 90 | 4.3.1 | Phase 2 ready for mass production | milestone, manual | 0d | 2023-05-01 | 2023-05-01 | 88, 87, 61 |  |  |  |
| 91 | 4.3.2 | Phase 2 Production M60 on top of Phase1 & 0 prod | manual | 392d | 2023-05-02 | 2024-10-30 | 90 |  | IFIC; IJCLAB; INFN; IPHC | 10976h |
| 92 | 4.3.3 | Phase 2 Production M84 | manual | 261d | 2023-05-02 | 2024-04-30 | 91 |  | IFIC; IJCLAB; INFN; IPHC | 7308h |
| 93 | 4.3.4 | Phase 2 Production M108 | manual | 262d | 2024-01-01 | 2024-12-31 | 92 |  | IFIC; IJCLAB; INFN; IPHC | 7336h |
| 94 | 4.3.5 | Phase 2 Production M132 | manual | 522d | 2025-01-01 | 2026-12-31 | 93 |  | IFIC; IJCLAB; INFN; IPHC | 14616h |
| 95 | 4.3.6 | Phase 2 Production M156 | manual | 522d | 2027-01-01 | 2028-12-31 | 94 |  | IFIC; IJCLAB; INFN; IPHC | 14616h |
| 96 | 4.3.7 | Phase 2 Production M180 | manual | 522d | 2029-01-01 | 2030-12-31 | 95 |  | IFIC; IJCLAB; INFN; IPHC | 14616h |
| 97 | 4.3.8 | Phase 2 upgrade to SMART | milestone, manual | 0d | 2026-01-02 | 2026-01-02 | 83 |  | IFIC; IJCLAB; INFN; IPHC |  |
| 98 | 4.4 | **Phase 1 Upgrade** |  | 783d | 2020-01-01 | 2022-12-31 |  | 0d |  | 11004h |
| 99 | 4.4.1 | Additionnal production to complete phase 0 & 1 ( 45 channels) | manual | 262d | 2020-01-01 | 2020-12-31 |  |  | IFIC; INFN; University of Valencia | 5502h |
| 100 | 4.4.2 | Additionnal production to replace phase 0 (45 channels) | manual | 262d | 2022-01-01 | 2022-12-31 |  |  | IFIC; INFN; University of Valencia | 5502h |
| 101 | 5 | **Data Processing** |  | 3262d? | 2020-01-01 | 2032-07-01 |  | 0d |  | 146678h |
| 102 | 5.1 | With Phase0 FEBEE | manual | 784d | 2020-01-01 | 2022-12-31 |  |  |  |  |
| 103 | 5.2 | With Phase1 FEBEE | manual | 1305d | 2020-01-01 | 2024-12-31 |  |  |  |  |
| 104 | 5.3 | With Phase2 FEBEE | manual | 2348d | 2022-01-03 | 2031-01-01 | 125 |  |  |  |
| 105 | 5.4 | End to Point to Point | milestone, manual | 0d | 2025-01-01 | 2025-01-01 | 103, 102, 93 |  |  |  |
| 106 | 5.5 | **Infrastructure** |  | 3262d | 2020-01-01 | 2032-07-01 |  | 0d |  | 33516h |
| 107 | 5.5.1 | HPC procurement 1pi | manual | 262d | 2020-01-01 | 2020-12-31 |  |  | IJCLAB | 1834h |
| 108 | 5.5.2 | HPC procurement 2pi | manual | 1172d | 2021-01-01 | 2025-06-30 | 107 |  | IJCLAB | 8204h |
| 109 | 5.5.3 | HPC procurement 3pi | manual | 784d | 2025-07-01 | 2028-06-30 | 108 |  | IJCLAB | 5488h |
| 110 | 5.5.4 | HPC procurement 4pi | manual | 1044d | 2028-07-03 | 2032-07-01 | 109 |  | IJCLAB | 7308h |
| 111 | 5.5.5 | Upgrade CEPH 1Po | milestone, manual | 0d | 2026-01-01 | 2026-01-01 |  |  | IJCLAB |  |
| 112 | 5.5.6 | Irod Evaluation | manual | 502d | 2023-01-01 | 2024-12-01 |  |  | IJCLAB; IP2I | 7028h |
| 113 | 5.5.7 | Irod Test | manual | 261d | 2024-12-02 | 2025-12-01 | 112 |  | IJCLAB; IP2I | 3654h |
| 114 | 5.5.8 | Irod migration | milestone, manual | 0d | 2025-12-02 | 2025-12-02 | 113 |  | IJCLAB; IP2I |  |

| ID | WBS | Task | Type | Duration | Start | Finish | Predecessors | Total slack | Resources | Work |
| --- | --- | --- | --- | --- | --- | --- | --- | --- | --- | --- |
| 115 | 5.6 | **PSA** |  | 1043d? | 2021-01-01 | 2024-12-31 |  | 0d |  | 43806h |
| 116 | 5.6.1 | Event Dispatcher R&D | manual | 1043d | 2021-01-01 | 2024-12-31 |  |  | IJCLAB | 7301h |
| 117 | 5.6.2 | Cache optimization R&D | manual | 1043d | 2021-01-01 | 2024-12-31 |  |  | IJCLAB; IP2I | 14602h |
| 118 | 5.6.3 | GPU R&D | manual | 1043d | 2021-01-01 | 2024-12-31 |  |  | IP2I; IJCLAB; STFC | 21903h |
| 119 | 5.7 | **Flow** |  | 2607d | 2021-01-01 | 2030-12-30 |  | 0d |  | 25550h |
| 120 | 5.7.1 | Ethernet Dispatching design | manual | 1043d | 2021-01-01 | 2024-12-31 |  |  | IJCLAB | 7301h |
| 121 | 5.7.2 | Ethernet Dispatching | milestone, manual | 0d | 2025-01-01 | 2025-01-01 | 120, 126, 105 |  | IJCLAB |  |
| 122 | 5.7.3 | Dispatching Op | manual | 1564d | 2025-01-01 | 2030-12-30 | 121 |  | IJCLAB | 10948h |
| 123 | 5.7.4 | Software Trigger Design | manual | 1043d | 2021-01-01 | 2024-12-31 |  |  | IJCLAB | 7301h |
| 124 | 5.8 | **Services Software** |  | 1043d | 2021-01-01 | 2024-12-31 |  | 0d |  | 10962h |
| 125 | 5.8.1 | TM upgrade | manual | 261d | 2021-01-01 | 2021-12-31 |  |  | IJCLAB | 1827h |
| 126 | 5.8.2 | TM upgrade Phase2 | manual | 262d | 2024-01-01 | 2024-12-31 |  |  | IJCLAB | 1834h |
| 127 | 5.8.3 | GEC upgrade | manual | 1043d | 2021-01-01 | 2024-12-31 |  |  | IJCLAB | 7301h |
| 128 | 5.9 | **Tracking** |  | 781d | 2021-01-01 | 2023-12-31 |  | 0d |  | 32844h |
| 129 | 5.9.1 | Mix method | manual | 782d? | 2021-01-01 | 2023-12-31 |  |  | IP2I; LIverpool University; IJCLAB | 16422h |
| 130 | 5.9.2 | Machine Learning R&D | manual | 782d | 2021-01-01 | 2023-12-31 |  |  | IJCLAB; IP2I; LIverpool University | 16422h |
| 131 | 6 | **Infrastructure** |  | 2870d | 2019-01-01 | 2029-12-31 |  | 0d |  | 60011h |
| 132 | 6.1 | **Detectors Infrastructure** |  | 2870d | 2019-01-01 | 2029-12-31 |  | 0d |  | 36050h |
| 133 | 6.1.1 | Low Voltage Power Supply Phase 2 Developpement | manual | 524d | 2019-06-03 | 2021-06-03 |  |  | Irfu | 3668h |
| 134 | 6.1.2 | Low Voltage Power Supply Phase 2, 8 Unit production | manual | 151d | 2021-06-04 | 2021-12-31 | 133 |  | Irfu | 1057h |
| 135 | 6.1.3 | Low Voltage Power Supply Phase 2, 8 Unit production | manual | 132d | 2022-07-01 | 2022-12-31 |  |  | Irfu | 924h |
| 136 | 6.1.4 | Low Voltage Power Supply Phase 2, 8 Unit production | manual | 132d | 2023-07-01 | 2023-12-31 |  |  | Irfu | 924h |
| 137 | 6.1.5 | Low Voltage Power Supply Phase 2, 8 Unit production | manual | 132d | 2024-07-01 | 2024-12-31 |  |  | Irfu | 924h |
| 138 | 6.1.6 | Low Voltage Power Supply Phase 2, 8 Unit production | manual | 132d | 2025-07-01 | 2025-12-31 |  |  | Irfu | 924h |
| 139 | 6.1.7 | Low Voltage Power Supply Phase 2, 8 Unit production | manual | 132d | 2027-07-01 | 2027-12-31 |  |  | Irfu | 924h |
| 140 | 6.1.8 | Low Voltage Power Supply Phase 2, 8 Unit production | manual | 132d | 2028-07-01 | 2029-01-01 |  |  | Irfu | 924h |
| 141 | 6.1.9 | Low Voltage Power Supply Phase 2, 8 Unit production | manual | 132d | 2029-07-01 | 2029-12-31 |  |  | Irfu | 924h |
| 142 | 6.1.10 | High Voltage Power Supply Upgrade Study for beyond 2pi | manual | 523d | 2019-01-01 | 2020-12-31 |  |  | INFN | 3661h |
| 143 | 6.1.11 | High Voltage Power Supply Upgrade Procurement for beyond 2pi | manual | 523d | 2024-01-01 | 2025-12-31 | 142 |  | INFN | 3661h |
| 144 | 6.1.12 | Cryogenic plants Developpement | manual | 282d | 2019-06-03 | 2020-06-30 |  |  | Irfu | 1974h |
| 145 | 6.1.13 | Cryogenic plants Instalation 1 | manual | 133d | 2020-07-01 | 2021-01-01 |  |  | Irfu | 931h |
| 146 | 6.1.14 | Cryogenic plants Instalation 2 | manual | 132d | 2025-07-01 | 2025-12-31 |  |  | Irfu | 924h |
| 147 | 6.1.15 | Cryogenic plants Instalation 3 | manual | 392d | 2028-07-01 | 2029-12-31 |  |  | Irfu | 2744h |
| 148 | 6.1.16 | Crygenic plants ready | milestone | 0d | 2029-12-31 | 2029-12-31 | 147 | 1304d | Irfu |  |
| 149 | 6.1.17 | Analog cables and Optical fibers For 2Pi Procurement | manual | 261d | 2021-01-01 | 2021-12-31 |  |  | INFN | 1827h |
| 150 | 6.1.18 | Patch Boxes for 2Pi Procurement | manual | 261d | 2021-01-01 | 2021-12-31 |  |  | IPHC; University of Koeln | 3654h |
| 151 | 6.1.19 | Analog cables and Optical fibers For 4Pi | manual | 261d | 2026-01-01 | 2026-12-31 |  |  | FAIR | 1827h |
| 152 | 6.1.20 | Patch Boxes for 4Pi | manual | 261d | 2026-01-01 | 2026-12-31 |  |  | IPHC; University of Koeln | 3654h |

| ID | WBS | Task | Type | Duration | Start | Finish | Predecessors | Total slack | Resources | Work |
| --- | --- | --- | --- | --- | --- | --- | --- | --- | --- | --- |
| 153 | 6.2 | **Mechanical Structure** |  | 1828d | 2019-01-01 | 2026-01-01 |  | 0d |  | 23961h |
| 154 | 6.2.1 | Design | manual | 370d | 2019-01-01 | 2020-06-01 |  |  | STFC | 2590h |
| 155 | 6.2.2 | Shaft 1 production | manual | 153d | 2020-06-02 | 2020-12-31 | 154 |  | STFC | 1071h |
| 156 | 6.2.3 | 30 Flanges production | manual | 262d | 2020-01-01 | 2020-12-31 |  |  | INFN; University of Jyvaskyla | 3668h |
| 157 | 6.2.4 | LNL Installation and Survey | manual | 174d | 2021-01-01 | 2021-09-01 | 155, 156 |  | STFC; INFN | 2436h |
| 158 | 6.2.5 | Shaft 2 production | manual | 262d | 2024-01-01 | 2024-12-31 |  |  | STFC | 1834h |
| 159 | 6.2.6 | 30 Flanges production | manual | 262d | 2024-01-01 | 2024-12-31 |  |  | INFN; University of Jyvaskyla | 3668h |
| 160 | 6.2.7 | FAIR Installation and Survey | manual | 261d | 2025-01-01 | 2025-12-31 | 158, 159 |  | STFC; FAIR | 3654h |
| 161 | 6.2.8 | **CEM** |  | 1305d | 2021-01-01 | 2026-01-01 |  | 0d |  | 5040h |
| 162 | 6.2.8.1 | CEM-LNL | manual | 130d | 2021-01-01 | 2021-07-01 |  |  | IJCLAB; STFC; INFN | 2730h |
| 163 | 6.2.8.2 | CEM-FAIR | manual | 110d | 2025-08-01 | 2026-01-01 |  |  | IJCLAB; STFC; FAIR | 2310h |
| 164 | 7 | **PSA and Tracking** |  | 3131d | 2019-01-01 | 2030-12-31 |  | 0d |  | 226044h |
| 165 | 7.1 | Scanning Table Upgrades | manual | 523d | 2019-01-01 | 2020-12-31 |  |  | LIverpool University; IPHC; Salamanca University | 10983h |
| 166 | 7.2 | Scanning Characterization Activity Electronic Collimation and Pulse Shape Comparison Scan | manual | 2608d | 2021-01-01 | 2030-12-31 | 165 |  | IPHC; LIverpool University; Salamanca University | 54768h |
| 167 | 7.3 | Machine Learning and AI R&D | manual | 1107d | 2021-01-01 | 2025-03-31 |  |  | LIverpool University; IP2I; IJCLAB | 23247h |
| 168 | 7.4 | **Algorithms optimization** |  | 2608d | 2021-01-01 | 2030-12-31 |  |  | LIverpool University; IJCLAB; IP2I | 137046h |
| 169 | 7.4.1 | Error Estimation in PSA | manual | 784d | 2019-01-01 | 2021-12-31 |  |  | IJCLAB; IP2I; LIverpool University | 16464h |
| 170 | 7.4.2 | Basis Calculation and simulation | manual | 784d | 2020-01-01 | 2022-12-31 |  |  | IJCLAB; IP2I; LIverpool University | 16464h |
| 171 | 7.4.3 | CPU optimization | manual | 784d | 2019-01-01 | 2021-12-31 |  |  | IJCLAB; IP2I; LIverpool University | 16464h |
| 172 | 7.4.4 | Multi-Interaction Treatment | manual | 1566d | 2019-01-01 | 2024-12-31 |  |  | IJCLAB; IP2I; LIverpool University | 32886h |
| 173 | 8 | **Performance and Simulation** |  | 2869d | 2021-01-01 | 2031-12-31 |  | 0d |  | 222726h |
| 174 | 8.1 | AGATA response function (Distribution, correlations etc…) | manual | 2608d | 2021-01-01 | 2030-12-31 |  |  | IJCLAB; IP2I; INFN; STFC | 73024h |
| 175 | 8.2 | GEANT4 Package maintenance | manual | 2608d | 2021-01-01 | 2030-12-31 |  |  | STFC; IJCLAB | 36512h |
| 176 | 8.3 | GEANT4 To Root Analysis Package | manual | 1304d | 2021-01-01 | 2025-12-31 |  |  | STFC; IJCLAB | 18256h |
| 177 | 8.4 | GEANT4 Event Generator upgrade | manual | 2869d | 2021-01-01 | 2031-12-31 |  |  | STFC; IJCLAB | 40166h |
| 178 | 8.5 | Performance investigation | manual | 2608d | 2021-01-01 | 2030-12-31 |  |  | IJCLAB; INFN; IP2I | 54768h |
